# App de pagos digitales para pequeños y medianos comercios

Schedule from MS Project, 2024-03-01 to 2024-09-19, status date 2024-05-20, costs in $, A marks actual dates.

## Calendars

- CalendarioSoftpos: Mon-Fri 08:00-13:00, 14:00-18:00; Sat-Sun off. Exceptions (off unless hours are given): 2024-05-23.

## Resources

| Resource | Rate |
| --- | --- |
| Jefe técnico | 20000 |
| Gerente de proyecto | 21000 |
| Oficial de seguridad de la información | 16000 |
| Contador | 12000 |
| Asesor Jurídico | 14000 |
| Arquitecto 1 | 35000 |
| Arquitecto 2 | 35000 |
| Arquitecto 3 | 35000 |
| Arquitecto 4 | 35000 |
| Desarrollador 1 | 19000 |
| Desarrollador 2 | 19000 |
| Ingeniero técnico | 20000 |
| Tester 2 | 15000 |
| Diseñador | 12000 |
| Tarjetas de prueba |  |
| Almacenamiento | 11000000 |
| Servidores | 20000000 |
| Dominio e Ip | 4400000 |
| Certificado digital | 2000000 |
| Celular | 806750 |
| Suscripción | 99000 |
| Certificación Marcas | 11500000 |
| Cobro proveedor Desarrollo | 200000 |
| Tester 1 | 15000 |
| firewall | 9250000 |
| Ingeniero técnivo nivel 2 | 30000 |

## Schedule

| ID | WBS | Task | Type | Duration | Start | Finish | Predecessors | Complete | Remaining | Baseline start | Baseline finish | Baseline duration | Baseline 1 start | Baseline 1 finish | Total slack | Free slack | Constraint | Resources | Work | Actual work | Cost | Baseline cost | Actual cost |
| --- | --- | --- | --- | --- | --- | --- | --- | --- | --- | --- | --- | --- | --- | --- | --- | --- | --- | --- | --- | --- | --- | --- | --- |
| 1 | 1 | **Reuniones seguimiento** |  | 151.25d | 2024-03-01 A | 2024-09-06 |  | 43% | 86.43d | 2024-03-01 | 2024-09-06 | 151.25d | 2024-03-01 | 2024-09-06 | 9.75d |  |  |  | 32h | 12h | 548,000 | 548,000 | 168,000 |
| 2 | 1.1 | Reuniones seguimiento 1 |  | 0.5d | 2024-03-01 A | 2024-03-01 A |  | 100% |  | 2024-03-01 | 2024-03-01 | 0.5d | 2024-03-01 | 2024-03-01 |  |  | start no earlier than 2024-03-01 | Asesor Jurídico | 4h | 4h | 56,000 | 56,000 | 56,000 |
| 3 | 1.2 | Reuniones seguimiento 2 |  | 0.5d | 2024-04-05 A | 2024-04-05 A |  | 100% |  | 2024-04-05 | 2024-04-05 | 0.5d | 2024-04-05 | 2024-04-05 |  |  | start no earlier than 2024-04-05 | Contador | 4h | 4h | 48,000 | 48,000 | 48,000 |
| 4 | 1.3 | Reuniones seguimiento 3 |  | 0.5d | 2024-05-03 A | 2024-05-03 A |  | 100% |  | 2024-05-03 | 2024-05-03 | 0.5d | 2024-05-03 | 2024-05-03 |  |  | start no earlier than 2024-05-03 | Oficial de seguridad de la información | 4h | 4h | 64,000 | 64,000 | 64,000 |
| 5 | 1.4 | Reuniones seguimiento 4 |  | 0.5d | 2024-06-07 | 2024-06-07 |  |  |  | 2024-06-07 | 2024-06-07 | 0.5d | 2024-06-07 | 2024-06-07 | 82.88d |  | start no earlier than 2024-06-07 | Gerente de proyecto | 4h |  | 84,000 | 84,000 |  |
| 6 | 1.5 | Reuniones seguimiento 5 |  | 0.5d | 2024-07-05 | 2024-07-05 |  |  |  | 2024-07-05 | 2024-07-05 | 0.5d | 2024-07-05 | 2024-07-05 | 60.38d |  | start no earlier than 2024-07-05 | Gerente de proyecto; Jefe técnico | 8h |  | 164,000 | 164,000 |  |
| 7 | 1.6 | Reuniones seguimiento 6 |  | 0.5d | 2024-08-02 | 2024-08-02 |  |  |  | 2024-08-02 | 2024-08-02 | 0.5d | 2024-08-02 | 2024-08-02 | 37.88d |  | start no earlier than 2024-08-02 | Contador | 4h |  | 48,000 | 48,000 |  |
| 8 | 1.7 | Reuniones seguimiento 7 |  | 0.5d | 2024-09-06 | 2024-09-06 |  |  |  | 2024-09-06 | 2024-09-06 | 0.5d | 2024-09-06 | 2024-09-06 | 9.75d |  | start no earlier than 2024-09-06 | Gerente de proyecto | 4h |  | 84,000 | 84,000 |  |
| 9 | 2 | **Arquitectura y plataforma** |  | 36d | 2024-03-01 A | 2024-04-15 |  | 81% | 7d | 2024-03-01 | 2024-04-15 | 36d | 2024-03-01 | 2024-04-15 | 125d |  |  |  | 360h | 290h | 12,928,000 | 12,928,000 | 10,228,000 |
| 10 | 2.1 | **Diseño de solución** |  | 36d | 2024-03-01 A | 2024-04-15 |  | 81% | 7d | 2024-03-01 | 2024-04-15 | 36d | 2024-03-01 | 2024-04-15 | 125d |  |  |  | 360h | 290h | 12,928,000 | 12,928,000 | 10,228,000 |
| 11 | 2.1.1 | Inicio | milestone | 0d | 2024-03-01 | 2024-03-01 |  |  |  | 2024-03-01 | 2024-03-01 | 0d | 2024-03-01 | 2024-03-01 | 161d |  |  |  |  |  |  |  |  |
| 12 | 2.1.2 | Creación de lógica del negocio |  | 6d | 2024-03-01 A | 2024-03-08 A |  | 100% |  | 2024-03-01 | 2024-03-08 | 6d | 2024-03-01 | 2024-03-08 |  |  |  | Gerente de proyecto | 48h | 48h | 1,008,000 | 1,008,000 | 1,008,000 |
| 13 | 2.1.3 | Diseño de la arquitectura a nivel de desarrollo de la solución |  | 9d | 2024-03-08 A | 2024-04-01 A |  | 100% |  | 2024-03-08 | 2024-04-01 | 9d |  |  |  |  | start no earlier than 2024-03-08 | Arquitecto 1; Cobro proveedor Desarrollo | 72h | 72h | 2,720,000 | 2,720,000 | 2,720,000 |
| 14 | 2.1.4 | Diseño de la arquitectura a nivel de desarrollo de la solución |  | 9d | 2024-03-08 A | 2024-03-20 A | 12 | 100% |  | 2024-03-08 | 2024-03-20 | 9d | 2024-03-08 | 2024-03-20 |  |  |  | Cobro proveedor Desarrollo; Arquitecto 2 | 72h | 72h | 2,720,000 | 2,720,000 | 2,720,000 |
| 15 | 2.1.5 | Diseño de la arquitectura a nivel de infraestructura |  | 7d | 2024-03-20 A | 2024-03-28 | 14 | 75% | 1.75d | 2024-03-20 | 2024-03-28 | 7d | 2024-03-20 | 2024-03-28 | 1.75d | 0d |  | Arquitecto 2; Cobro proveedor Desarrollo | 56h | 42h | 2,160,000 | 2,160,000 | 1,620,000 |
| 16 | 2.1.6 | Diseño de la arquitectura a nivel de comunicaciones |  | 7d | 2024-03-28 A | 2024-04-05 | 15 | 25% | 5.25d | 2024-03-28 | 2024-04-05 | 7d | 2024-03-28 | 2024-04-05 | 1.25d | 0d |  | Cobro proveedor Desarrollo; Arquitecto 3 | 56h | 14h | 2,160,000 | 2,160,000 | 540,000 |
| 17 | 2.1.7 | Diseño de la arquitectura a nivel de seguridad |  | 7d | 2024-04-05 A | 2024-04-15 | 16 | 75% | 1.75d | 2024-04-05 | 2024-04-15 | 7d | 2024-04-05 | 2024-04-15 | 89d | 14d |  | Cobro proveedor Desarrollo; Arquitecto 4 | 56h | 42h | 2,160,000 | 2,160,000 | 1,620,000 |
| 18 | 3 | **Infraestructura** |  | 46d | 2024-03-28 A | 2024-05-27 |  | 35% | 29.9d | 2024-03-28 | 2024-05-27 | 46d | 2024-03-28 | 2024-05-27 | 75d |  |  |  | 480h | 168h | 102,650,000 | 102,650,000 | 49,685,000 |
| 19 | 3.1 | **Habilitación de comunicaciones** |  | 10d | 2024-04-05 A | 2024-04-18 |  | 50% | 5d | 2024-04-05 | 2024-04-18 | 10d | 2024-04-05 | 2024-04-18 | 5.5d |  |  |  | 80h | 40h | 2,400,000 | 2,400,000 | 1,300,000 |
| 20 | 3.1.1 | Despliegue de virtual networks y acceso a internet |  | 5d | 2024-04-05 A | 2024-04-12 | 16 | 25% | 3.75d | 2024-04-05 | 2024-04-12 | 5d | 2024-04-05 | 2024-04-12 | 3.75d | 0d |  | Cobro proveedor Desarrollo; Ingeniero técnico | 40h | 10h | 1,000,000 | 1,000,000 | 250,000 |
| 21 | 3.1.2 | Configuración de servicios de red (DNS, NTP) |  | 5d | 2024-04-12 A | 2024-04-18 | 20 | 75% | 1.25d | 2024-04-12 | 2024-04-18 | 5d | 2024-04-12 | 2024-04-18 | 5.5d | 0d |  | Cobro proveedor Desarrollo; Ingeniero técnivo nivel 2 | 40h | 30h | 1,400,000 | 1,400,000 | 1,050,000 |
| 22 | 3.2 | **Despliegue de recursos de computo** |  | 28d | 2024-03-28 A | 2024-05-02 |  | 50% | 14d | 2024-03-28 | 2024-05-02 | 28d | 2024-03-28 | 2024-05-02 | 75d |  |  |  | 256h | 128h | 96,770,000 | 96,770,000 | 48,385,000 |
| 23 | 3.2.1 | Adquisión de infraestructura |  | 16d | 2024-03-28 A | 2024-04-17 | 15 | 50% | 8d | 2024-03-28 | 2024-04-17 | 16d | 2024-03-28 | 2024-04-17 | 6.5d | 1d |  | Jefe técnico; Almacenamiento [300%]; Dominio e Ip [150%]; Certificado digital; firewall | 128h | 64h | 53,410,000 | 53,410,000 | 26,705,000 |
| 24 | 3.2.2 | Configuración de conectividad |  | 5d | 2024-04-05 A | 2024-04-12 | 16 | 50% | 2.5d | 2024-04-05 | 2024-04-12 | 5d | 2024-04-05 | 2024-04-12 | 10.5d | 5d |  | Cobro proveedor Desarrollo; Ingeniero técnivo nivel 2 | 40h | 20h | 1,400,000 | 1,400,000 | 700,000 |
| 25 | 3.2.3 | Instalación y configuración de servidores |  | 11d | 2024-04-18 A | 2024-05-02 | 21, 23, 24 | 50% | 5.5d | 2024-04-18 | 2024-05-02 | 11d | 2024-04-18 | 2024-05-02 | 75d | 0d |  | Cobro proveedor Desarrollo; Ingeniero técnico; Servidores [200%] | 88h | 44h | 41,960,000 | 41,960,000 | 20,980,000 |

| ID | WBS | Task | Duration | Start | Finish | Predecessors | Baseline start | Baseline finish | Baseline duration | Baseline 1 start | Baseline 1 finish | Total slack | Free slack | Resources | Work | Cost | Baseline cost |
| --- | --- | --- | --- | --- | --- | --- | --- | --- | --- | --- | --- | --- | --- | --- | --- | --- | --- |
| 26 | 3.3 | **Aseguramiento de la plataforma** | 18d | 2024-05-02 | 2024-05-27 |  | 2024-05-02 | 2024-05-27 | 18d | 2024-05-02 | 2024-05-27 | 75d |  |  | 144h | 3,480,000 | 3,480,000 |
| 27 | 3.3.1 | Aplicación de Hardening de los sistemas implicados basados en PCI DSS | 5d | 2024-05-02 | 2024-05-08 | 17, 25 | 2024-05-02 | 2024-05-08 | 5d | 2024-05-02 | 2024-05-08 | 75d | 0d | Cobro proveedor Desarrollo; Ingeniero técnico | 40h | 1,000,000 | 1,000,000 |
| 28 | 3.3.2 | Aplicación Hacking ético | 7d | 2024-05-08 | 2024-05-17 | 27 | 2024-05-08 | 2024-05-17 | 7d | 2024-05-08 | 2024-05-17 | 75d | 0d | Cobro proveedor Desarrollo; Ingeniero técnico | 56h | 1,320,000 | 1,320,000 |
| 29 | 3.3.3 | Corrección a las vulnerabilidades encontradas | 6d | 2024-05-17 | 2024-05-27 | 28 | 2024-05-17 | 2024-05-27 | 6d | 2024-05-17 | 2024-05-27 | 75d |  | Cobro proveedor Desarrollo; Ingeniero técnico | 48h | 1,160,000 | 1,160,000 |
| 30 | 4 | **Desarrollo de la aplicación** | 128d | 2024-03-20 | 2024-08-28 |  | 2024-03-20 | 2024-08-28 | 128d | 2024-03-20 | 2024-08-28 | 0d |  |  | 1224h | 39,887,000 | 39,887,000 |
| 31 | 4.1 | **Desarrollo del sistema back-end** | 20d | 2024-03-20 | 2024-04-15 |  | 2024-03-20 | 2024-04-15 | 20d | 2024-03-20 | 2024-04-15 | 0d |  |  | 192h | 4,048,000 | 4,048,000 |
| 32 | 4.1.1 | Escritura del código | 20d | 2024-03-20 | 2024-04-15 | 14 | 2024-03-20 | 2024-04-15 | 20d | 2024-03-20 | 2024-04-15 | 0d |  | Cobro proveedor Desarrollo; Desarrollador 1 | 160h | 3,240,000 | 3,240,000 |
| 33 | 4.1.2 | Gestión bases de datos | 4d | 2024-03-20 | 2024-03-25 | 14 | 2024-03-20 | 2024-03-25 | 4d | 2024-03-20 | 2024-03-25 | 16d |  | Cobro proveedor Desarrollo; Desarrollador 2 | 32h | 808,000 | 808,000 |
| 34 | 4.2 | **Desarrollo del sistema front-end** | 38d | 2024-04-15 | 2024-05-31 |  | 2024-04-15 | 2024-05-31 | 38d | 2024-04-15 | 2024-05-31 | 0d |  |  | 344h | 6,936,000 | 6,936,000 |
| 35 | 4.2.1 | Escritura del código | 11d | 2024-04-15 | 2024-04-26 | 32, 33 | 2024-04-15 | 2024-04-26 | 11d | 2024-04-15 | 2024-04-26 | 0d |  | Cobro proveedor Desarrollo; Desarrollador 2 | 88h | 1,872,000 | 1,872,000 |
| 36 | 4.2.2 | Integración de APIs y bibliotecas | 9d | 2024-04-26 | 2024-05-08 | 35 | 2024-04-26 | 2024-05-08 | 9d | 2024-04-26 | 2024-05-08 | 0d |  | Cobro proveedor Desarrollo; Desarrollador 2 | 72h | 1,568,000 | 1,568,000 |
| 37 | 4.2.3 | Integración del frontend con el backend | 4d | 2024-05-08 | 2024-05-14 | 36 | 2024-05-08 | 2024-05-14 | 4d | 2024-05-08 | 2024-05-14 | 0d |  | Cobro proveedor Desarrollo; Desarrollador 1 | 32h | 808,000 | 808,000 |
| 38 | 4.2.4 | Creación de interfas de usuarios | 8d | 2024-05-14 | 2024-05-24 | 37 | 2024-05-14 | 2024-05-24 | 8d | 2024-05-14 | 2024-05-24 | 0d |  | Cobro proveedor Desarrollo; Diseñador | 64h | 968,000 | 968,000 |
| 39 | 4.2.5 | Pruebas de funcionalidad | 5d | 2024-05-24 | 2024-05-30 | 38 | 2024-05-24 | 2024-05-30 | 5d | 2024-05-24 | 2024-05-30 | 1d |  | Tester 1; Cobro proveedor Desarrollo | 40h | 800,000 | 800,000 |
| 40 | 4.2.6 | Pruebas de rendimiento | 6d | 2024-05-24 | 2024-05-31 | 38 | 2024-05-24 | 2024-05-31 | 6d | 2024-05-24 | 2024-05-31 | 0d |  | Cobro proveedor Desarrollo; Tester 2 | 48h | 920,000 | 920,000 |
| 41 | 4.3 | **Despliegue de los desarrollos en la infraestructura** | 4d | 2024-05-31 | 2024-06-06 |  | 2024-05-31 | 2024-06-06 | 4d | 2024-05-31 | 2024-06-06 | 0d |  |  | 32h | 840,000 | 840,000 |
| 42 | 4.3.1 | Desplegar las aplicaciones desarrolladas a los recursos de computo desplegados para la solución en entorno de pruebas | 4d | 2024-05-31 | 2024-06-06 | 39, 40 | 2024-05-31 | 2024-06-06 | 4d | 2024-05-31 | 2024-06-06 | 0d |  | Cobro proveedor Desarrollo; Ingeniero técnico | 32h | 840,000 | 840,000 |
| 43 | 4.4 | **Pruebas de calidad** | 4d | 2024-06-06 | 2024-06-11 |  | 2024-06-06 | 2024-06-11 | 4d | 2024-06-06 | 2024-06-11 | 0d |  |  | 56h | 1,240,000 | 1,240,000 |
| 44 | 4.4.1 | Garantizar la resiliencia de la aplicación en caso de fallos de la infraestructura | 4d | 2024-06-06 | 2024-06-11 | 42 | 2024-06-06 | 2024-06-11 | 4d | 2024-06-06 | 2024-06-11 | 0d |  | Cobro proveedor Desarrollo; Tester 2 | 32h | 680,000 | 680,000 |
| 45 | 4.4.2 | Garantizar que la aplicación funcione correctamente sin errores inesperados | 3d | 2024-06-06 | 2024-06-11 | 42 | 2024-06-06 | 2024-06-11 | 3d | 2024-06-06 | 2024-06-11 | 1d |  | Cobro proveedor Desarrollo; Tester 1 | 24h | 560,000 | 560,000 |
| 46 | 4.5 | **Certificación de aliados** | 84d | 2024-05-14 | 2024-08-28 |  | 2024-05-14 | 2024-08-28 | 84d | 2024-05-14 | 2024-08-28 | 0d |  |  | 600h | 26,823,000 | 26,823,000 |
| 47 | 4.5.1 | Obtención del set de pruebas del aliado | 6d | 2024-05-14 | 2024-05-21 | 37 | 2024-05-14 | 2024-05-21 | 6d | 2024-05-14 | 2024-05-21 | 16d |  | Gerente de proyecto | 48h | 1,008,000 | 1,008,000 |
| 48 | 4.5.2 | Análisis y correcciones que apliquen para garantizar la correcta ejecución de las pruebas | 7d | 2024-06-12 | 2024-06-20 | 44, 45, 47 | 2024-06-12 | 2024-06-20 | 7d | 2024-06-12 | 2024-06-20 | 0d |  | Cobro proveedor Desarrollo; Desarrollador 1; Desarrollador 2 | 112h | 2,328,000 | 2,328,000 |
| 49 | 4.5.3 | Ejecución del set de pruebas de manera interna | 4d | 2024-06-20 | 2024-06-25 | 48 | 2024-06-20 | 2024-06-25 | 4d | 2024-06-20 | 2024-06-25 | 0d |  | Desarrollador 1; Celular [200%]; Tarjetas de prueba [1000%]; Cobro proveedor Desarrollo | 32h | 2,421,500 | 2,421,500 |
| 50 | 4.5.4 | Revisión del set de pruebas con el aliado | 51d | 2024-06-25 | 2024-08-28 | 49 | 2024-06-25 | 2024-08-28 | 51d | 2024-06-25 | 2024-08-28 | 0d |  | Desarrollador 1; Celular [200%]; Tarjetas de prueba [1000%]; Cobro proveedor Desarrollo; Certificación Marcas | 408h | 21,065,500 | 21,065,500 |

| ID | WBS | Task | Type | Duration | Start | Finish | Predecessors | Baseline start | Baseline finish | Baseline duration | Baseline 1 start | Baseline 1 finish | Total slack | Resources | Work | Cost | Baseline cost |
| --- | --- | --- | --- | --- | --- | --- | --- | --- | --- | --- | --- | --- | --- | --- | --- | --- | --- |
| 51 | 5 | **Puesta en producción** |  | 69d | 2024-06-25 | 2024-09-19 |  | 2024-06-25 | 2024-09-19 | 69d | 2024-06-25 | 2024-09-19 | 0d |  | 176h | 3,987,000 | 3,987,000 |
| 52 | 5.1 | **Promoción de la aplicación al ambiente productivo** |  | 11d | 2024-08-28 | 2024-09-10 |  | 2024-08-28 | 2024-09-10 | 11d | 2024-08-28 | 2024-09-10 | 0d |  | 88h | 1,960,000 | 1,960,000 |
| 53 | 5.1.1 | Desplegar las aplicaciones desarrolladas a los recursos de computo desplegados para la solución en entorno de producción |  | 8d | 2024-08-28 | 2024-09-06 | 29, 50 | 2024-08-28 | 2024-09-06 | 8d | 2024-08-28 | 2024-09-06 | 0d | Cobro proveedor Desarrollo; Ingeniero técnico | 64h | 1,480,000 | 1,480,000 |
| 54 | 5.1.2 | Verficar el correcto funcionamiento de la aplicación en producción |  | 3d | 2024-09-06 | 2024-09-10 | 53 | 2024-09-06 | 2024-09-10 | 3d | 2024-09-06 | 2024-09-10 | 0d | Jefe técnico | 24h | 480,000 | 480,000 |
| 55 | 5.2 | **App disponible en tienda Android** |  | 69d | 2024-06-25 | 2024-09-19 |  | 2024-06-25 | 2024-09-19 | 69d | 2024-06-25 | 2024-09-19 | 0d |  | 88h | 2,027,000 | 2,027,000 |
| 56 | 5.2.1 | Adquisición de cuenta en Google Play |  | 4d | 2024-06-25 | 2024-07-01 | 49 | 2024-06-25 | 2024-07-01 | 4d | 2024-06-25 | 2024-07-01 | 58d | Jefe técnico; Suscripción | 32h | 739,000 | 739,000 |
| 57 | 5.2.2 | Despliegue de la aplicación en la Play store |  | 4d | 2024-09-10 | 2024-09-16 | 54, 56 | 2024-09-10 | 2024-09-16 | 4d | 2024-09-10 | 2024-09-16 | 0d | Cobro proveedor Desarrollo; Desarrollador 2 | 32h | 808,000 | 808,000 |
| 58 | 5.2.3 | Verificar la correcta publicación de la aplicación |  | 3d | 2024-09-16 | 2024-09-19 | 57 | 2024-09-16 | 2024-09-19 | 3d | 2024-09-16 | 2024-09-19 | 0d | Jefe técnico | 24h | 480,000 | 480,000 |
| 59 | 5.2.4 | Fin | milestone | 0d | 2024-09-19 | 2024-09-19 | 58 | 2024-09-19 | 2024-09-19 | 0d | 2024-09-19 | 2024-09-19 | 0d |  |  |  |  |
